# Projekt_jo_02_03

Schedule from MS Project, 2008-10-27 to 2009-04-30, status date 2008-11-07, costs in Ft.
iqjb

## Calendars

- Szabványos: Mon-Fri 08:00-12:00, 13:00-17:00; Sat-Sun off.

## Resources

| Resource | Unit | Rate |
| --- | --- | --- |
| Á hálózatépítő 1 |  | 1500 |
| Á műszaki informatikus 1 |  | 1500 |
| Á adminisztrátor 1 |  | 1000 |
| Kovács Anita |  | 6000 |
| Kiss Attila |  | 10000 |
| Nagy Annamária |  | 1200 |
| Paál Anikó |  | 1300 |
| Kőbán Péter |  | 4200 |
| Rétlaki Géza |  | 4400 |
| Mároki Teréz |  | 1400 |
| Mosolygó Ferenc |  | 4100 |
| Téglás Csaba |  | 1200 |
| Podorek Paula |  | 4100 |
| Tiefenghalter Eszter |  | 1200 |
| Szakócza István |  | 3900 |
| Késmárki Lilla |  | 4000 |
| Á hálózatépítő 2 |  | 1500 |
| Á műszaki informatikus 2 |  | 1500 |
| Á adminisztrátor 2 |  | 1000 |
| Á műszaki informatikus 3 |  | 1500 |
| Á adminisztrátor 3 |  | 1000 |
| Á adminisztrátor 4 |  | 1000 |
| Számítógép beszerzési költségek | eFt | 1000 |
| Hálózatépítés költségei | eFt | 1000 |
| Egyéb költségek | eFt | 1000 |
| Á programozó 3 |  | 4500 |
| Á programozó 4 |  | 4500 |
| Á_projektszponzor |  | 8000 |
| Á oktató 1 |  | 4000 |
| Á oktató 2 |  | 4000 |
| Á oktató 3 |  | 4000 |
| Á műszaki informatikus 4 |  | 1500 |
| Kő Pál |  | 1200 |
| Kiss Irén |  | 1200 |
| Nagy Armand |  | 1200 |
| Beke Botond |  | 1200 |
| Kőváry Laura |  | 1200 |
| Kőpataki Tihamér |  | 2100 |
| Baumgartner Karina |  |  |
| Mathiugasz Gitisz |  | 6000 |
| Oktatók |  |  |
| Műszaki szakemberek |  |  |
| Telepítési csoport |  |  |
| Á programozó 1 |  | 4500 |
| Á programozó 2 |  | 4500 |
| Á_projektmenedzser |  | 6000 |
| Á megbízó koordinátor 1 |  | 2500 |
| Á megbízó koordinátor 2 |  | 2500 |
| Kiss Edit |  | 7000 |
| Molnár Noémi |  | 7000 |
| Nyári Éva |  | 2500 |

## Schedule

| ID | WBS | Task | Type | Duration | Start | Finish | Predecessors | Total slack | Free slack | Resources | Work | Cost | Text29 | nap, óra |
| --- | --- | --- | --- | --- | --- | --- | --- | --- | --- | --- | --- | --- | --- | --- |
| 1 | 1 | **Célmeghatározás** |  | 21.5d | 2008-10-27 | 2008-11-25 |  | 96.5d |  |  | 692h | 2,125,000 | 480 | 21 n, 4 ó |
| 2 | 1.1 | Projektindító értekezlet |  | 1d | 2008-10-27 | 2008-10-27 |  | 96.5d | 0d | Á műszaki informatikus 1; Á műszaki informatikus 2; Á műszaki informatikus 3; Á műszaki informatikus 4; Á programozó 1; Á programozó 2; Á programozó 3; Á programozó 4; Á_projektszponzor; Á_projektmenedzser | 80h | 304,000 | 480 | 1 n |
| 3 | 1.2 | Tárolandó dokumentumtípusok megismerése |  | 3d | 2008-10-28 | 2008-10-30 | 2 | 97.5d | 0d | Á műszaki informatikus 1; Á műszaki informatikus 3; Á programozó 1; Á programozó 2; Á programozó 3; Á programozó 4 | 144h | 504,000 | 480 | 3 n |
| 4 | 1.3 | Jelenlegi dokumentumkezelési eljárások megismerése |  | 2d | 2008-10-31 | 2008-11-03 | 3 | 97.5d | 1d | Á műszaki informatikus 1; Á műszaki informatikus 3; Á programozó 1; Á programozó 2; Á programozó 3; Á programozó 4 | 96h | 336,000 | 480 | 2 n |
| 5 | 1.4 | Az új rendszerrel szemben támasztott követelmények összeállítása |  | 6d | 2008-10-28 | 2008-11-04 | 2 | 96.5d | 0d | Nyári Éva; Á megbízó koordinátor 2 | 96h | 264,000 | 480 | 6 n |
| 6 | 1.5 | Megbízó oldali céldokumentum kész | milestone | 0d | 2008-11-04 | 2008-11-04 | 5 | 96.5d | 0d |  |  |  | 480 | --mérföldkő-- |
| 7 | 1.6 | Eredmények ismertetése |  | 4h | 2008-11-05 | 2008-11-05 | 6, 4 | 96.5d | 0d | Á megbízó koordinátor 1; Á műszaki informatikus 1; Á műszaki informatikus 3; Á programozó 1; Á programozó 2; Á programozó 3; Á programozó 4 | 28h | 94,000 | 480 | 4 ó |
| 8 | 1.7 | felhasználói interjúk készítése |  | 8d | 2008-11-06 | 2008-11-17 | 7FS+0.5d | 96.5d | 0d | Á műszaki informatikus 1; Á műszaki informatikus 2; Egyéb költségek [67 eFt] | 128h | 259,000 | 480 | 8 n |
| 9 | 1.8 | felhasználói interjúk kiértékelése |  | 2d | 2008-11-07 | 2008-11-11 | 8SS+1.5d | 101d | 4.5d | Á műszaki informatikus 1 | 16h | 24,000 | 480 | 2 n |
| 10 | 1.9 | Az IT oldal javaslata az új rendszer specifikációjához |  | 4d | 2008-11-18 | 2008-11-21 | 9, 8 | 96.5d | 0d | Á műszaki informatikus 3; Á programozó 1 | 64h | 192,000 | 480 | 4 n |
| 11 | 1.10 | IT oldali céldokumentum kész | milestone | 0d | 2008-11-21 | 2008-11-21 | 10 | 96.5d | 0d |  |  |  | 480 | --mérföldkő-- |
| 12 | 1.11 | IT oldali céldokumentum megvitatása |  | 4h | 2008-11-24 | 2008-11-24 | 11 | 96.5d | 0d | Á műszaki informatikus 3; Á programozó 1; Á megbízó koordinátor 1; Á megbízó koordinátor 2; Kiss Edit; Molnár Noémi | 24h | 100,000 | 480 | 4 ó |
| 13 | 1.12 | Módosítások elkészítése |  | 1d | 2008-11-24 | 2008-11-25 | 12 | 96.5d | 0d | Á programozó 1; Á műszaki informatikus 3 | 16h | 48,000 | 480 | 1 n |
| 14 | 1.13 | Céldokumentum elfogadása | milestone | 0d | 2008-11-25 | 2008-11-25 | 13 | 96.5d | 0d |  |  |  | 480 | --mérföldkő-- |
| 15 | 2 | **Tervezés** |  | 13d | 2008-11-25 | 2008-12-12 |  | 96.5d |  |  | 256h | 540,000 | 480 | 13 n |
| 16 | 2.1 | Üzemeltetési jellemzők kidolgozása |  | 6d | 2008-11-25 | 2008-12-03 | 14 | 96.5d | 0d | Á műszaki informatikus 1; Á műszaki informatikus 3 | 96h | 144,000 | 480 | 6 n |
| 17 | 2.2 | Prototípus kidolgozása az üzemeltetési jellemzők alapján |  | 4d | 2008-12-03 | 2008-12-09 | 16 | 96.5d | 0d | Á műszaki informatikus 1; Á műszaki informatikus 3 | 64h | 96,000 | 480 | 4 n |
| 18 | 2.3 | Funkcionális specifikációk áttekintése |  | 3d | 2008-12-09 | 2008-12-12 | 17 | 96.5d | 0d | Á műszaki informatikus 1; Á megbízó koordinátor 1; Á megbízó koordinátor 2; Á_projektmenedzser | 96h | 300,000 | 480 | 3 n |
| 19 | 2.4 | Döntés a továbblépésről | milestone | 0d | 2008-12-12 | 2008-12-12 | 18 | 96.5d | 0d | Á_projektszponzor |  |  | 480 | --mérföldkő-- |
| 20 | 2.5 | Tervezés kész | milestone | 0d | 2008-12-12 | 2008-12-12 | 19 | 96.5d | 0d |  |  |  | 480 | --mérföldkő-- |
| 21 | 3 | **Fejlesztés** |  | 3d | 2008-12-12 | 2008-12-17 |  | 96.5d |  |  | 88h | 408,000 | 480 | 3 n |
| 22 | 3.1 | Funkcionális specifikációk áttekintése |  | 1d | 2008-12-12 | 2008-12-15 | 20 | 96.5d | 0d | Á programozó 1; Á programozó 2; Á programozó 3; Á programozó 4 | 32h | 144,000 | 480 | 1 n |
| 23 | 3.2 | Moduláris vagy réteges tervparaméterek azonosítása |  | 1d | 2008-12-15 | 2008-12-16 | 22 | 96.5d | 0d | Á programozó 1; Á programozó 2 | 16h | 72,000 | 480 | 1 n |
| 24 | 3.3 | Fejlesztőgárda hozzárendelése |  | 1d | 2008-12-16 | 2008-12-17 | 23 | 96.5d |  | Á programozó 1; Á programozó 2; Á programozó 3; Á programozó 4; Á_projektmenedzser | 40h | 192,000 | 480 | 1 n |

| ID | WBS | Task | Duration | Start | Finish | Predecessors | Total slack | Resources | Work | Cost | Text29 | nap, óra |
| --- | --- | --- | --- | --- | --- | --- | --- | --- | --- | --- | --- | --- |
| 25 | 4 | **Tesztelés** | 60d | 2008-10-27 | 2009-01-16 |  | 0d |  | 2400h | 7,200,000 | 480 | 60 n |
| 26 | 4.1 | Tesztelés | 60d | 2008-10-27 | 2009-01-16 |  | 0d | Á műszaki informatikus 2; Á műszaki informatikus 4; Á oktató 1; Á oktató 2; Á oktató 3 | 2400h | 7,200,000 | 480 | 60 n |
| 27 | 5 | **Dokumentáció** | 25d | 2009-01-01 | 2009-02-04 |  | 31d |  | 800h | 3,400,000 |  | 25 n |
| 28 | 5.1 | Dokumentáció készítése | 25d | 2009-01-01 | 2009-02-04 | 26FS-12d | 31d | Á programozó 1; Á programozó 2; Á oktató 1; Á oktató 2 | 800h | 3,400,000 | 480 | 25 n |
| 29 | 6 | **Próba** | 40d | 2009-01-19 | 2009-03-13 |  | 0d |  | 1280h | 3,520,000 |  | 40 n |
| 30 | 6.1 | Próbaüzem | 40d | 2009-01-19 | 2009-03-13 | 26 | 0d | Á műszaki informatikus 2; Á műszaki informatikus 3; Á oktató 1; Á oktató 2 | 1280h | 3,520,000 | 480 | 40 n |
| 31 | 7 | **Telepítés** | 4d | 2009-03-16 | 2009-03-19 |  | 0d |  | 64h | 96,000 | 480 | 4 n |
| 32 | 7.1 | Telepítés | 4d | 2009-03-16 | 2009-03-19 | 30 | 0d | Á műszaki informatikus 1; Á műszaki informatikus 2 | 64h | 96,000 | 480 | 4 n |
| 33 | 8 | **Továbbképzés** | 30d | 2009-03-20 | 2009-04-30 |  | 0d |  | 744h | 2,916,000 | 480 | 30 n |
| 34 | 8.1 | Továbbképzés | 30d | 2009-03-20 | 2009-04-30 | 32, 28 | 0d | Á oktató 1; Á oktató 2; Á oktató 3; Á műszaki informatikus 2 [10%] | 744h | 2,916,000 | 480 | 30 n |
